# OB-04 - met kelder

Schedule from MS Project, 2003-01-12 to 2003-02-13, status date 2003-01-08.
BAM Nelissen Van Egteren

## Calendars

- ALLEEN WERKDAGEN: Mon-Fri 08:30-12:30, 13:00-17:00; Sat-Sun off. Exceptions (off unless hours are given): 2003-01-11 to 2003-01-12 08:30-12:30, 13:00-17:00, 2003-01-18 to 2003-01-19 08:30-12:30, 13:00-17:00, 2003-01-25 to 2003-01-26 08:30-12:30, 13:00-17:00, 2003-02-01 to 2003-02-02 08:30-12:30, 13:00-17:00, 2003-02-08 to 2003-02-09 08:30-12:30, 13:00-17:00.

## Schedule

| ID | WBS | Task | Type | Duration | Start | Finish | Predecessors | Total slack |
| --- | --- | --- | --- | --- | --- | --- | --- | --- |
| 1 | 1 | **ONDERBOUWFASE** |  | 33d | 2003-01-12 | 2003-02-13 |  | 0d |
| 2 | 1.1 | werkvloer randkist+beton |  | 3d | 2003-01-12 | 2003-01-14 |  | 0d |
| 3 | 1.2 | randkist keldervloer |  | 2d | 2003-01-14 | 2003-01-15 | 2SS+2d | 0d |
| 4 | 1.3 | vloerwapening vlechten |  | 3d | 2003-01-15 | 2003-01-17 | 3SS+1d | 0d |
| 5 | 1.4 | leidingen in keldervloer |  | 2d | 2003-01-17 | 2003-01-18 | 4SS+2d | 0d |
| 6 | 1.5 | keldervloer beton storten |  | 1d | 2003-01-19 | 2003-01-19 | 5SS+2d | 0d |
| 7 | 1.6 | maatvoeren wanden+kolommen |  | 1d | 2003-01-20 | 2003-01-20 | 6SS+1d | 0d |
| 8 | 1.7 | kolommen kist+wap+beton |  | 6d | 2003-01-21 | 2003-01-26 | 7SS+1d | 0d |
| 9 | 1.8 | kelderwand bekisting stellen |  | 6d | 2003-01-22 | 2003-01-27 | 8SS+1d | 0d |
| 10 | 1.9 | kelderwand wapening vlechten |  | 6d | 2003-01-24 | 2003-01-29 | 9SS+2d | 0d |
| 11 | 1.10 | sluitwand bekisting stellen |  | 6d | 2003-01-26 | 2003-01-31 | 10SS+2d | 0d |
| 12 | 1.11 | kelderwanden beton storten |  | 6d | 2003-01-27 | 2003-02-01 | 11SS+1d | 0d |
| 13 | 1.12 | kelderwanden ontkisten |  | 6d | 2003-01-29 | 2003-02-03 | 12SS+2d | 0d |
| 14 | 1.13 | beg.grond vloerbekisting stellen |  | 6d | 2003-02-03 | 2003-02-08 | 13SS+5d | 0d |
| 15 | 1.14 | beg.grond vloerwap. vlechten |  | 4d | 2003-02-07 | 2003-02-10 | 14SS+4d | 0d |
| 16 | 1.15 | vloerleidingen monteren |  | 2d | 2003-02-10 | 2003-02-11 | 15SS+3d | 0d |
| 17 | 1.16 | beg.grondvloer beton storten |  | 1d | 2003-02-12 | 2003-02-12 | 16SS+2d | 0d |
| 18 | 1.17 | maatvoeren voor bovenbouw |  | 1d | 2003-02-13 | 2003-02-13 | 17SS+1d | 0d |
| 19 | 1.18 | start bovenbouw | milestone | 0d | 2003-02-13 | 2003-02-13 | 18SS+1d | 0d |
